Schedule from MS Project, 2020-06-01 to 2021-10-21.
Microsoft

## Calendars

- Standardno: Mon-Fri 08:00-12:00, 13:00-17:00; Sat-Sun off.

## Schedule

| ID | WBS | Task | Type | Duration | Start | Finish | Predecessors | Total slack | Free slack |
| --- | --- | --- | --- | --- | --- | --- | --- | --- | --- |
| 1 | 1 | **Uvodne aktivnosti na projektu** |  | 20d | 2020-06-01 | 2020-06-26 |  | 1d | 0d |
| 2 | 1.1 | Zbiranje dokumentacije sistema eŠtudent |  | 5d | 2020-06-01 | 2020-06-05 |  | 10d |  |
| 3 | 1.2 | Zbiranje idej za funkcionalnosti s strani zaposlenih na FRI |  | 10d | 2020-06-01 | 2020-06-12 |  | 5d |  |
| 4 | 1.3 | Sestavljanje projektne ekipe |  | 15d | 2020-06-01 | 2020-06-19 |  | 1d | 0d |
| 5 | 1.4 | KickOff meeting |  | 5d | 2020-06-22 | 2020-06-26 | 2, 3, 4 | 1d |  |
| 7 | 2 | **Izbor in namestitev programske opreme** |  | 25d | 2020-06-29 | 2020-07-31 | 1 | 1d | 0d |
| 8 | 2.1 | Izbor programske opreme na strani strežnika |  | 10d | 2020-06-29 | 2020-07-10 |  | 1d | 0d |
| 9 | 2.2 | Izbor programske produkta za razvoj |  | 10d | 2020-06-29 | 2020-07-10 |  | 1d | 0d |
| 10 | 2.3 | Izbor ostale prograsmske opreme |  | 10d | 2020-06-29 | 2020-07-10 |  | 1d | 0d |
| 11 | 2.4 | Nabava programske opreme |  | 10d | 2020-07-13 | 2020-07-24 | 8, 9, 10 | 1d | 0d |
| 12 | 2.5 | Namestitve programske opreme na strani strežnika |  | 5d | 2020-07-27 | 2020-07-31 | 11 | 1d |  |
| 13 | 2.6 | Namestitve programske opreme za razvoj |  | 2d | 2020-07-27 | 2020-07-28 | 11 | 4d |  |
| 14 | 2.7 | Namestitve ostale programske opreme |  | 2d | 2020-07-27 | 2020-07-28 | 11 | 4d |  |
| 16 | 3 | **Faza analize** |  | 43d | 2020-08-03 | 2020-09-30 | 7 | 1d |  |
| 17 | 3.1 | Zbiranje zahtev in pričakovanj |  | 30d | 2020-08-03 | 2020-09-11 |  | 53d |  |
| 18 | 3.2 | **Opredelitev vseh potrebnih funkcionalnosti** |  | 27d | 2020-08-03 | 2020-09-08 |  | 1d | 0d |
| 19 | 3.2.1 | Izvedba prvega cikla delavnic za opredelitev funkcionalnosti |  | 10d | 2020-08-03 | 2020-08-14 |  | 1d | 0d |
| 20 | 3.2.2 | Analiza opredeljenih funkcionalnosti |  | 10d | 2020-08-10 | 2020-08-21 | 19SS+5d | 1d | 0d |
| 21 | 3.2.3 | Izvedba drugega cikla delavnic za opredelitev funkcionalnosti |  | 10d | 2020-08-24 | 2020-09-04 | 20 | 1d | 0d |
| 22 | 3.2.4 | Analiza opredeljenih funkcionalnosti |  | 8d | 2020-08-28 | 2020-09-08 | 21SS+4d | 1d | 0d |
| 23 | 3.3 | Izdelava dokumenta za opredelitev funkcionalnosti |  | 7d | 2020-09-09 | 2020-09-17 | 22 | 1d | 0d |
| 24 | 3.4 | **Izdelava diagramov in drugih izdelkov** |  | 9d | 2020-09-18 | 2020-09-30 | 23 | 1d | 0d |
| 25 | 3.4.1 | Izdelava diagramov primerov uporabe |  | 5d | 2020-09-18 | 2020-09-24 |  | 5d |  |
| 26 | 3.4.2 | Izdelava konceptualnega podatkovnega modela |  | 9d | 2020-09-18 | 2020-09-30 |  | 1d |  |
| 27 | 3.4.3 | Izdelava ostalih diagramov in izdelkov |  | 7d | 2020-09-18 | 2020-09-28 |  | 3d |  |
| 28 | 3.5 | Faza analize zaključena | milestone | 0d | 2020-09-30 | 2020-09-30 | 24 | 1d | 0d |

| ID | WBS | Task | Type | Duration | Start | Finish | Predecessors | Total slack | Free slack |
| --- | --- | --- | --- | --- | --- | --- | --- | --- | --- |
| 30 | 4 | **Faza načrtovanja** |  | 65d | 2020-09-09 | 2020-12-08 |  | 17d |  |
| 31 | 4.1 | **Zasnova in razvoj uporabniškega vmesnika** |  | 28d | 2020-09-09 | 2020-10-16 | 18 | 264d |  |
| 32 | 4.1.1 | Razvoj treh variant uporabnišekga vmesnika |  | 15d | 2020-09-09 | 2020-09-29 |  | 28d | 0d |
| 33 | 4.1.2 | Delavnice glede uporabniškega vmesnika |  | 5d | 2020-09-30 | 2020-10-06 | 32 | 28d | 0d |
| 34 | 4.1.3 | Izbor vmesnika in opredelitev smernic za dokončanje |  | 3d | 2020-10-07 | 2020-10-09 | 33 | 28d | 0d |
| 35 | 4.1.4 | Razvoj končne verzije uporabniškega vmesnika |  | 5d | 2020-10-12 | 2020-10-16 | 34 | 28d |  |
| 36 | 4.2 | **Načrtovanje arhitekture sistema** |  | 13d | 2020-10-01 | 2020-10-19 | 28 | 1d | 0d |
| 37 | 4.2.1 | Zasnova arhitekture sistema |  | 3d | 2020-10-01 | 2020-10-05 |  | 11d |  |
| 38 | 4.2.2 | Izdelava osnutka diagramov arhitekture sistema |  | 4d | 2020-10-01 | 2020-10-06 |  | 1d | 0d |
| 39 | 4.2.3 | Izvedba delavnic za načrtovanje arhitekture sistema |  | 5d | 2020-10-07 | 2020-10-13 | 38 | 1d | 0d |
| 40 | 4.2.4 | Finalizacija načrta arhitekture sistema |  | 4d | 2020-10-14 | 2020-10-19 | 39 | 1d |  |
| 41 | 4.3 | **Načrtovanje podatkovne baze** |  | 6d | 2020-10-13 | 2020-10-20 | 36SS+8d | 0d |  |
| 42 | 4.3.1 | Izdelava logičnega podatkovnega modela |  | 2d | 2020-10-13 | 2020-10-14 |  | 1d |  |
| 43 | 4.3.2 | Analiza dodatnih potrebnih indeksov |  | 3d | 2020-10-13 | 2020-10-15 |  | 0d |  |
| 44 | 4.3.3 | Finalizacija načrta podatkovne baze |  | 3d | 2020-10-16 | 2020-10-20 | 42, 43 | 0d |  |
| 45 | 4.4 | Načrtovanje modulov sistema |  | 20d | 2020-10-21 | 2020-11-17 | 36, 41 | 15d |  |
| 46 | 4.5 | **Načrtovanje migracije podatkov** |  | 35d | 2020-10-21 | 2020-12-08 | 36, 41 | 0d |  |
| 47 | 4.5.1 | Izvedba delavnice za migracijo podatkov |  | 5d | 2020-10-21 | 2020-10-27 |  | 0d |  |
| 48 | 4.5.2 | Analiza rezlutatov delavnice |  | 5d | 2020-10-28 | 2020-11-03 | 47 | 0d |  |
| 49 | 4.5.3 | Izdelava plana za migracijo podatkov |  | 10d | 2020-11-04 | 2020-11-17 | 48 | 0d |  |
| 50 | 4.5.4 | Izdelava načrta programskih objektov za migracijio podatkov |  | 15d | 2020-11-18 | 2020-12-08 | 49 | 0d |  |
| 51 | 4.5.5 | Izdelava načrta form za migracijo podatkov |  | 15d | 2020-11-18 | 2020-12-08 | 49 | 0d |  |
| 52 | 4.5.6 | Izdelava načrta testnith programov za migracijo podatkov |  | 15d | 2020-11-18 | 2020-12-08 | 49 | 0d |  |
| 53 | 4.6 | Faza načrtovanja zaključena | milestone | 0d | 2020-12-08 | 2020-12-08 | 41, 46, 45 | 0d |  |

| ID | WBS | Task | Duration | Start | Finish | Predecessors | Total slack |
| --- | --- | --- | --- | --- | --- | --- | --- |
| 55 | 5 | **Faza implementacije** | 227d | 2020-12-09 | 2021-10-21 | 53 | 0d |
| 56 | 5.1 | **Priprava razvojnega okolja** | 5d | 2020-12-09 | 2020-12-15 |  | 0d |
| 57 | 5.1.1 | Priprava okolja za razvijalce | 5d | 2020-12-09 | 2020-12-15 |  | 0d |
| 58 | 5.1.2 | Priprava okolja za razvoj za migracijo podatkov | 5d | 2020-12-09 | 2020-12-15 |  | 0d |
| 59 | 5.2 | Izvedba prve faze razvoja za migracijo podatkov | 10d | 2020-12-16 | 2020-12-29 | 56 | 0d |
| 60 | 5.3 | Izvedba prve faze migracije podatkov | 5d | 2020-12-30 | 2021-01-05 | 59 | 0d |
| 61 | 5.4 | **Implementacija sistema** | 112d | 2021-01-06 | 2021-06-10 | 60 | 0d |
| 62 | 5.4.1 | Implementacija modula Šifranti | 10d | 2021-01-06 | 2021-01-19 |  | 22d |
| 63 | 5.4.2 | Implemantacija modula Predmetnik | 15d | 2021-01-06 | 2021-01-26 |  | 0d |
| 64 | 5.4.3 | Implementacija modula Vpis | 20d | 2021-01-22 | 2021-02-18 | 63FS-3d | 0d |
| 65 | 5.4.4 | Evaluacija modulov in izvedba testiranj | 10d | 2021-02-19 | 2021-03-04 | 62, 63, 64 | 0d |
| 66 | 5.4.5 | Analiza testiranj in opredelitev smernic za potrebne spremembe | 5d | 2021-03-05 | 2021-03-11 | 65 | 0d |
| 67 | 5.4.6 | Implementacija potrebnih sprememb na modulih Šifranti, Predmetnik in Vpis | 10d | 2021-03-12 | 2021-03-25 | 66 | 0d |
| 68 | 5.4.7 | Implementacija ostalih modulov | 20d | 2021-03-26 | 2021-04-22 | 67 | 0d |
| 69 | 5.4.8 | Testiranje ostalih modulov | 10d | 2021-04-23 | 2021-05-06 | 68 | 0d |
| 70 | 5.4.9 | Analiza testiranj in opredelitev smernic za potrebne spremembe | 5d | 2021-05-07 | 2021-05-13 | 69 | 0d |
| 71 | 5.4.10 | Implementacija potrebnih sprememb na ostalih modulih | 20d | 2021-05-14 | 2021-06-10 | 70 | 0d |
| 72 | 5.5 | **Izvedba druge faze migracije podatkov** | 40d | 2021-06-11 | 2021-08-05 | 61 | 0d |
| 73 | 5.5.1 | Razvoj programov in form za migracijo podatkov | 10d | 2021-06-11 | 2021-06-24 |  | 0d |
| 74 | 5.5.2 | Testiranje programov in form za migracijo podatkov | 5d | 2021-06-25 | 2021-07-01 | 73 | 0d |
| 75 | 5.5.3 | Izvedba druge faze migracije podatkov | 10d | 2021-07-02 | 2021-07-15 | 74 | 0d |
| 76 | 5.5.4 | Testiranje druge faze migracije in izvedba potrebnih korekcij | 15d | 2021-07-16 | 2021-08-05 | 75 | 0d |
| 77 | 5.6 | **Izobraževenje uporabnikov za uporabo sistema** | 20d | 2021-08-06 | 2021-09-02 | 72 | 0d |
| 78 | 5.6.1 | Izdelava plana uvajanja sistema v uporabo | 5d | 2021-08-06 | 2021-08-12 |  | 15d |
| 79 | 5.6.2 | Izdelava plana izobraževanj | 5d | 2021-08-06 | 2021-08-12 |  | 0d |
| 80 | 5.6.3 | Priprava okolja za izobraževanje uporabnikov | 5d | 2021-08-13 | 2021-08-19 | 79 | 10d |
| 81 | 5.6.4 | Priprava gradiv za izobraževanje | 5d | 2021-08-13 | 2021-08-19 | 79 | 0d |
| 82 | 5.6.5 | Izvedba vseh izobraževanj | 10d | 2021-08-20 | 2021-09-02 | 81 | 0d |

| ID | WBS | Task | Duration | Start | Finish | Predecessors | Total slack |
| --- | --- | --- | --- | --- | --- | --- | --- |
| 83 | 5.7 | **Zaključno testiranje sistema** | 35d | 2021-09-03 | 2021-10-21 | 77 | 0d |
| 84 | 5.7.1 | Priprava tesnega okolja | 5d | 2021-09-03 | 2021-09-09 |  | 30d |
| 85 | 5.7.2 | Ponovna izvedba vseh migracij podatkov | 3d | 2021-09-03 | 2021-09-07 |  | 32d |
| 86 | 5.7.3 | Izdelava testnih scenarijev | 25d | 2021-09-03 | 2021-10-07 |  | 0d |
| 87 | 5.7.4 | Izdelava plana testiranj | 10d | 2021-09-24 | 2021-10-07 | 86SS+15d | 0d |
| 88 | 5.7.5 | Izvedba potrditvenega testa | 10d | 2021-10-08 | 2021-10-21 | 87 | 0d |
